# Planowanie kampanii marketingowej

Schedule from MS Project, 2023-03-20 to 2023-12-29.
Pomyślnie zakończone kampanie są zwykle oparte na dokładnych badaniach, są wszechstronnie przemyślane i koncentrują się na szczegółach oraz wykonaniu. Planowanie kampanii marketingowej rozpoczyna się od określenia pozycji firmy na rynku, a kończy się na gromadzeniu danych i analizie efektywności kampanii. W tym szablonie wyszczególniono różne zagadnienia, które warto wziąć pod uwagę podczas planowania kampanii marketingowej w swojej organizacji.

## Calendars

- Standardowy: Mon-Fri 09:00-13:00, 14:00-18:00; Sat-Sun off.

## Resources

| Resource |
| --- |
| Lider zarządzania logistycznego |
| Lider marketingu |
| Sponsor |
| Sprzedaż |
| Dział kreatywny |
| Konsultant zawartości |
| Marketing |
| Badania marketingowe |
| Firma sponsorująca |
| Ekspert |
| Wewnętrzny dział sprzedaży |
| Personel działu marketingu |
| Marketing produktów |
| Dyrektor regionalny |
| Dyrektor krajowy |
| Lider aliansów strategicznych |
| Przedstawiciel ds. marketingu |
| Badania marketingowe |
| Wewnętrzny dział relacji publicznych |
| Firma z branży relacji publicznych |
| Sprzedawca |

## Schedule

| ID | WBS | Task | Type | Duration | Start | Finish | Predecessors | Total slack | Free slack | Resources | Work |
| --- | --- | --- | --- | --- | --- | --- | --- | --- | --- | --- | --- |
| 1 | 1 | **Przegląd strategii biznesowej** |  | 27d? | 2023-03-20 | 2023-04-25 |  | 0d |  |  | 256h |
| 2 | 1.1 | Określenie luk i szans sprzedaży usług/produktów |  | 5d? | 2023-03-20 | 2023-03-24 |  | 0d |  | Lider marketingu | 40h |
| 3 | 1.2 | Przeprowadzenie analizy SWOT |  | 5d? | 2023-03-27 | 2023-03-31 | 2 | 0d |  | Lider marketingu | 40h |
| 4 | 1.3 | Przegląd modelu działalności firmy |  | 1d? | 2023-04-03 | 2023-04-03 | 3 | 0d |  | Lider marketingu | 8h |
| 5 | 1.4 | Przegląd strategii marketingowej organizacji |  | 3d? | 2023-04-04 | 2023-04-06 | 4 | 0d |  | Lider marketingu | 24h |
| 6 | 1.5 | Przegląd lokalnej strategii marketingowej |  | 1d? | 2023-04-07 | 2023-04-07 | 5 | 0d |  | Lider marketingu | 8h |
| 7 | 1.6 | Przegląd globalnej strategii marketingowej |  | 1d? | 2023-04-10 | 2023-04-10 | 6 | 0d |  | Przedstawiciel ds. marketingu | 8h |
| 8 | 1.7 | Przegląd planu marketingowego dla budżetu kampanii |  | 1d? | 2023-04-11 | 2023-04-11 | 7 | 0d |  | Przedstawiciel ds. marketingu | 8h |
| 9 | 1.8 | Ustalenie docelowych rynków ekspansji dla organizacji |  | 1d? | 2023-04-12 | 2023-04-12 | 8 | 0d |  | Lider marketingu | 8h |
| 10 | 1.9 | Ocena zgodności z celami strategii firmowej |  | 2d? | 2023-04-13 | 2023-04-14 | 9 | 0d |  | Lider marketingu; Sponsor | 32h |
| 11 | 1.10 | Oszacowanie przewag konkurencyjnych |  | 3d? | 2023-04-17 | 2023-04-19 | 10 | 0d |  | Lider marketingu; Badania marketingowe | 48h |
| 12 | 1.11 | Przegląd marż od produktów i usług |  | 3d? | 2023-04-20 | 2023-04-24 | 11 | 0d |  | Lider marketingu | 24h |
| 13 | 1.12 | Przegląd efektywności poprzedniej kampanii |  | 1d? | 2023-04-25 | 2023-04-25 | 12 | 0d |  | Lider marketingu | 8h |
| 14 | 1.13 | Zakończenie przeglądu strategii biznesowej | milestone | 0d | 2023-04-25 | 2023-04-25 | 13 | 0d |  |  |  |
| 15 | 2 | **Opracowanie koncepcji kampanii** |  | 49d? | 2023-04-26 | 2023-07-03 |  | 0d |  |  | 504h |
| 16 | 2.1 | Utworzenie procesu kwalifikacji pomysłów |  | 5d? | 2023-04-26 | 2023-05-02 | 14 | 0d |  | Personel działu marketingu | 40h |
| 17 | 2.2 | Ustalenie procesu na potrzeby wymiany pomysłów |  | 5d? | 2023-05-03 | 2023-05-09 | 16 | 0d |  | Personel działu marketingu | 40h |
| 18 | 2.3 | Zgromadzenie pomysłów |  | 1d? | 2023-05-10 | 2023-05-10 | 17 | 0d |  |  |  |
| 19 | 2.4 | Nadanie ostatecznego kształtu i opracowanie pomysłów |  | 5d? | 2023-05-11 | 2023-05-17 | 18 | 0d |  | Lider marketingu | 40h |
| 20 | 2.5 | Badanie środowiska rynkowego |  | 5d? | 2023-05-18 | 2023-05-24 | 19 | 0d |  | Badania marketingowe | 40h |
| 21 | 2.6 | Opracowanie wstępnych koncepcji kampanii |  | 5d? | 2023-05-25 | 2023-05-31 | 20 | 0d |  | Lider marketingu | 40h |
| 22 | 2.7 | Określenie celów kampanii |  | 2d? | 2023-06-01 | 2023-06-02 | 21 | 0d |  | Lider marketingu | 16h |
| 23 | 2.8 | Opracowanie kryteriów sukcesu kampanii |  | 2d? | 2023-06-05 | 2023-06-06 | 22 | 0d |  | Przedstawiciel ds. marketingu | 16h |
| 24 | 2.9 | Opracowanie procesu śledzenia i analizy kampanii |  | 3d? | 2023-06-07 | 2023-06-09 | 23 | 0d |  | Personel działu marketingu | 24h |
| 25 | 2.10 | Zatwierdzenie koncepcji na podstawie informacji o grupach testowych i badań rynku |  | 5d? | 2023-06-12 | 2023-06-16 | 24 | 0d |  | Przedstawiciel ds. marketingu | 40h |
| 26 | 2.11 | Ustalenie listy priorytetów kampanii |  | 1d? | 2023-06-19 | 2023-06-19 | 25 | 0d |  | Przedstawiciel ds. marketingu | 8h |
| 27 | 2.12 | Ustalenie kategorii kampanii |  | 1d? | 2023-06-20 | 2023-06-20 | 26 | 5d | 0d | Przedstawiciel ds. marketingu | 8h |
| 28 | 2.13 | Opracowanie strategii relacji publicznych |  | 3d? | 2023-06-21 | 2023-06-23 | 27 | 5d | 0d | Wewnętrzny dział relacji publicznych | 24h |
| 29 | 2.14 | Ustalenie wstępnego idealnego chronometrażu kampanii dla promocji |  | 1d? | 2023-06-26 | 2023-06-26 | 28 | 5d |  | Przedstawiciel ds. marketingu | 8h |
| 30 | 2.15 | Określenie regionalnych kampanii organizacji |  | 5d? | 2023-06-20 | 2023-06-26 | 26 | 0d |  | Lider marketingu | 40h |
| 31 | 2.16 | Określenie globalnych kampanii organizacji |  | 5d? | 2023-06-20 | 2023-06-26 | 26 | 0d |  | Lider marketingu | 40h |
| 32 | 2.17 | Określenie krajowych kampanii organizacji |  | 5d? | 2023-06-20 | 2023-06-26 | 26 | 0d |  | Lider marketingu | 40h |
| 33 | 2.18 | Określenie wymagań lokalizacji |  | 5d? | 2023-06-27 | 2023-07-03 | 30, 31, 32 | 0d |  | Personel działu marketingu | 40h |
| 34 | 2.19 | Zakończenie opracowywania koncepcji kampanii | milestone | 0d | 2023-07-03 | 2023-07-03 | 33, 29 | 0d |  |  |  |

Notes:
- 3: Analiza SWOT mocne i słabe strony firmy, jej szanse i zagrożenia

| ID | WBS | Task | Type | Duration | Start | Finish | Predecessors | Total slack | Free slack | Resources | Work |
| --- | --- | --- | --- | --- | --- | --- | --- | --- | --- | --- | --- |
| 35 | 3 | **Utworzenie strategii lokalizacji** |  | 18d? | 2023-07-04 | 2023-07-27 |  | 0d |  |  | 224h |
| 36 | 3.1 | Przegląd firmowych celów sprzedaży |  | 1d? | 2023-07-04 | 2023-07-04 | 34 | 0d |  | Personel działu marketingu | 8h |
| 37 | 3.2 | Przegląd regionalnych modeli działalności firmy |  | 1d? | 2023-07-04 | 2023-07-04 | 34 | 0d |  | Przedstawiciel ds. marketingu | 8h |
| 38 | 3.3 | Przegląd globalnych/krajowych modeli działalności firmy |  | 1d? | 2023-07-04 | 2023-07-04 | 34 | 0d |  | Przedstawiciel ds. marketingu | 8h |
| 39 | 3.4 | Przegląd celów marketingowych |  | 1d? | 2023-07-04 | 2023-07-04 | 34 | 0d |  | Przedstawiciel ds. marketingu | 8h |
| 40 | 3.5 | Przegląd planu marketingowego |  | 1d? | 2023-07-04 | 2023-07-04 | 34 | 0d |  | Przedstawiciel ds. marketingu | 8h |
| 41 | 3.6 | Ustalenie szans sprzedaży dla kampanii |  | 3d? | 2023-07-05 | 2023-07-07 | 36, 37, 38, 39, 40 | 0d |  | Przedstawiciel ds. marketingu | 24h |
| 42 | 3.7 | Przegląd oferty mieszanej usług i produktów (elementów marketingu mix) oraz prognozy |  | 3d? | 2023-07-10 | 2023-07-12 | 41 | 0d |  | Przedstawiciel ds. marketingu | 24h |
| 43 | 3.8 | Przegląd cyklu wydania produktów |  | 3d? | 2023-07-13 | 2023-07-17 | 42 | 6d |  | Przedstawiciel ds. marketingu | 24h |
| 44 | 3.9 | Określenie elementów marketingu mix kampanii dla każdego regionu |  | 3d? | 2023-07-13 | 2023-07-17 | 42 | 0d |  | Lider marketingu | 24h |
| 45 | 3.10 | Określenie miar sukcesu kampanii dla każdego regionu |  | 3d? | 2023-07-18 | 2023-07-20 | 44 | 0d |  | Lider marketingu; Dyrektor regionalny | 48h |
| 46 | 3.11 | Określenie mechanizmu śledzenia |  | 3d? | 2023-07-21 | 2023-07-25 | 45 | 0d |  | Personel działu marketingu | 24h |
| 47 | 3.12 | Utworzenie strategii lokalizacji |  | 2d? | 2023-07-26 | 2023-07-27 | 46, 44, 43 | 0d |  | Personel działu marketingu | 16h |
| 48 | 3.13 | Zakończenie tworzenia strategii lokalizacji | milestone | 0d | 2023-07-27 | 2023-07-27 | 47 | 0d |  |  |  |
| 49 | 4 | **Komunikacja i szkolenie wewnątrz organizacji** |  | 24d? | 2023-07-28 | 2023-08-30 |  | 0d |  |  | 240h |
| 50 | 4.1 | Ustalenie firmowego procesu wewnętrznej komunikacji |  | 3d? | 2023-07-28 | 2023-08-01 | 48 | 0d |  | Personel działu marketingu | 24h |
| 51 | 4.2 | Określenie procesu komunikacji dla oddziałów regionalnych i krajowych |  | 5d? | 2023-08-02 | 2023-08-08 | 50 | 0d |  | Personel działu marketingu | 40h |
| 52 | 4.3 | Zaplanowanie metod, logistyki i chronometrażu komunikacji |  | 4d? | 2023-08-09 | 2023-08-14 | 51 | 0d |  | Lider zarządzania logistycznego; Personel działu marketingu | 64h |
| 53 | 4.4 | Regionalne i krajowe kanały komunikacji z działem sprzedaży, działem marketingu i kierownictwem |  | 5d? | 2023-08-15 | 2023-08-21 | 52 | 0d |  | Przedstawiciel ds. marketingu | 40h |
| 54 | 4.5 | Określenie wewnętrznych systemów odpowiedzi na kampanię |  | 5d? | 2023-08-22 | 2023-08-28 | 53 | 0d |  | Personel działu marketingu | 40h |
| 55 | 4.6 | Utworzenie planu komunikacji |  | 2d? | 2023-08-29 | 2023-08-30 | 54 | 0d |  |  |  |
| 56 | 4.7 | Określenie wymagań dotyczących wewnętrznego szkolenia |  | 1d? | 2023-07-28 | 2023-07-28 | 48 | 20d | 0d | Personel działu marketingu | 8h |
| 57 | 4.8 | Opracowanie wewnętrznego szkolenia |  | 3d? | 2023-07-31 | 2023-08-02 | 56 | 20d |  | Personel działu marketingu | 24h |
| 58 | 4.9 | Zakończenie opracowywania wewnętrznych sposobów komunikowania i wewnętrznego szkolenia dla organizacji | milestone | 0d | 2023-08-30 | 2023-08-30 | 55, 57 | 0d |  |  |  |

| ID | WBS | Task | Type | Duration | Start | Finish | Predecessors | Total slack | Free slack | Resources | Work |
| --- | --- | --- | --- | --- | --- | --- | --- | --- | --- | --- | --- |
| 59 | 5 | **Zarządzanie relacjami z klientami** |  | 16d? | 2023-07-28 | 2023-08-18 |  | 8d |  |  | 152h |
| 60 | 5.1 | Przegląd danych i opinii klientów |  | 3d? | 2023-07-28 | 2023-08-01 | 48 | 8d | 0d | Personel działu marketingu | 24h |
| 61 | 5.2 | Przegląd segmentów i kanałów firmy |  | 3d? | 2023-07-28 | 2023-08-01 | 48 | 8d | 0d | Personel działu marketingu | 24h |
| 62 | 5.3 | Określenie celów dla każdej kampanii |  | 3d? | 2023-08-02 | 2023-08-04 | 60, 61 | 8d | 0d | Badania marketingowe | 24h |
| 63 | 5.4 | Segmentowanie danych dla każdej kampanii |  | 5d? | 2023-08-07 | 2023-08-11 | 62 | 8d | 0d | Personel działu marketingu | 40h |
| 64 | 5.5 | Przygotowanie/uzyskanie list dla każdej kampanii |  | 5d? | 2023-08-14 | 2023-08-18 | 63 | 8d | 0d | Personel działu marketingu | 40h |
| 65 | 5.6 | Zakończenie zarządzania relacjami z klientami | milestone | 0d | 2023-08-18 | 2023-08-18 | 64 | 8d |  |  |  |
| 66 | 6 | **Analiza regionalnych/globalnych/krajowych modeli działalności firmy** |  | 9d? | 2023-07-28 | 2023-08-09 |  | 15d |  |  | 88h |
| 67 | 6.1 | Ustalenie regionów docelowych |  | 1d? | 2023-07-28 | 2023-07-28 | 48 | 15d | 0d | Personel działu marketingu | 8h |
| 68 | 6.2 | Określenie lokalnych luk |  | 2d? | 2023-07-31 | 2023-08-01 | 67 | 15d | 0d | Personel działu marketingu | 16h |
| 69 | 6.3 | Przegląd lokalnej konkurencji |  | 3d? | 2023-08-02 | 2023-08-04 | 68 | 15d | 0d | Badania marketingowe | 24h |
| 70 | 6.4 | Opracowanie przewagi konkurencyjnej |  | 2d? | 2023-08-07 | 2023-08-08 | 69 | 15d | 0d | Lider marketingu; Badania marketingowe | 32h |
| 71 | 6.5 | Określenie partnerów docelowych |  | 1d? | 2023-08-09 | 2023-08-09 | 70 | 15d | 0d | Lider aliansów strategicznych | 8h |
| 72 | 6.6 | Zakończenie analizy regionalnych/globalnych/krajowych modeli działalności firmy | milestone | 0d | 2023-08-09 | 2023-08-09 | 71 | 15d |  |  |  |
| 73 | 7 | **Opracowanie kampanii** |  | 14d? | 2023-08-31 | 2023-09-19 |  | 0d |  |  | 104h |
| 74 | 7.1 | Przegląd koncepcji kampanii |  | 2d? | 2023-08-31 | 2023-09-01 | 58, 65, 72 | 0d |  | Lider marketingu | 16h |
| 75 | 7.2 | Utworzenie listy kampanii |  | 1d? | 2023-09-04 | 2023-09-04 | 74 | 0d |  | Przedstawiciel ds. marketingu | 8h |
| 76 | 7.3 | Określenie liderów kampanii |  | 1d? | 2023-09-05 | 2023-09-05 | 75 | 0d |  | Przedstawiciel ds. marketingu | 8h |
| 77 | 7.4 | Opracowanie indywidualnych kampanii |  | 1d? | 2023-09-06 | 2023-09-06 | 76 | 0d |  |  |  |
| 78 | 7.5 | Opracowanie harmonogramów kampanii |  | 2d? | 2023-09-07 | 2023-09-08 | 77 | 0d |  | Przedstawiciel ds. marketingu | 16h |
| 79 | 7.6 | Określenie wezwań do akcji |  | 2d? | 2023-09-11 | 2023-09-12 | 78 | 0d |  | Lider marketingu | 16h |
| 80 | 7.7 | Określenie metod i elementów marketingu mix promocji/reklamy |  | 5d? | 2023-09-13 | 2023-09-19 | 79 | 0d |  | Lider marketingu | 40h |
| 81 | 7.8 | Zakończenie opracowywania kampanii | milestone | 0d | 2023-09-19 | 2023-09-19 | 80 | 0d |  |  |  |
| 82 | 8 | **Opracowanie projektu realizacji i testowanie kampanii** |  | 30d? | 2023-09-20 | 2023-10-31 |  | 0d |  |  | 312h |
| 83 | 8.1 | Wybranie dostawcy projektu realizacji |  | 1d? | 2023-09-20 | 2023-09-20 | 81 | 0d |  | Lider marketingu; Przedstawiciel ds. marketingu | 16h |
| 84 | 8.2 | Określenie stylu wiadomości/przesłania kampanii |  | 3d? | 2023-09-21 | 2023-09-25 | 83 | 0d |  | Lider marketingu; Dział kreatywny | 48h |
| 85 | 8.3 | Opracowanie koncepcji i konwencji |  | 5d? | 2023-09-26 | 2023-10-02 | 84 | 0d |  | Dział kreatywny | 40h |
| 86 | 8.4 | Wybranie projektu realizacji kampanii |  | 5d? | 2023-10-03 | 2023-10-09 | 85 | 0d |  | Lider marketingu; Firma sponsorująca | 80h |
| 87 | 8.5 | Przygotowanie materiałów do testowania wstępnego |  | 5d? | 2023-10-10 | 2023-10-16 | 86 | 0d |  | Przedstawiciel ds. marketingu | 40h |
| 88 | 8.6 | Testowanie wstępne kampanii |  | 5d? | 2023-10-17 | 2023-10-23 | 87 | 0d |  | Przedstawiciel ds. marketingu | 40h |
| 89 | 8.7 | Określenie, czy wstępnie testowany projekt realizacji kampanii osiąga założone cele |  | 1d? | 2023-10-24 | 2023-10-24 | 88 | 0d |  | Przedstawiciel ds. marketingu | 8h |
| 90 | 8.8 | Ulepszenie projektu realizacji na podstawie wyników testów wstępnych |  | 5d? | 2023-10-25 | 2023-10-31 | 89 | 0d |  | Dział kreatywny | 40h |
| 91 | 8.9 | Zakończenie opracowywania projektu realizacji i testowania kampanii | milestone | 0d | 2023-10-31 | 2023-10-31 | 90 | 0d |  |  |  |

| ID | WBS | Task | Type | Duration | Start | Finish | Predecessors | Total slack | Free slack | Resources | Work |
| --- | --- | --- | --- | --- | --- | --- | --- | --- | --- | --- | --- |
| 92 | 9 | **Opracowanie strategii zewnętrznych promocji** |  | 9d? | 2023-11-01 | 2023-11-13 |  | 0d |  |  | 368h |
| 93 | 9.1 | Opracowanie strategii promocji |  | 2d? | 2023-11-01 | 2023-11-02 | 91 | 0d |  | Lider marketingu; Wewnętrzny dział relacji publicznych | 32h |
| 94 | 9.2 | Opracowanie informacji prasowych |  | 4d? | 2023-11-03 | 2023-11-08 | 93 | 0d |  | Wewnętrzny dział relacji publicznych; Firma z branży relacji publicznych | 64h |
| 95 | 9.3 | Opracowanie anonsów |  | 4d? | 2023-11-03 | 2023-11-08 | 93 | 0d |  | Wewnętrzny dział relacji publicznych; Firma z branży relacji publicznych | 64h |
| 96 | 9.4 | Dostarczenie wstępnych informacji analitykom |  | 3d? | 2023-11-09 | 2023-11-13 | 94, 95 | 0d |  | Wewnętrzny dział relacji publicznych; Firma z branży relacji publicznych | 48h |
| 97 | 9.5 | Nagłośnienie wydarzenia |  | 5d? | 2023-11-03 | 2023-11-09 | 93 | 2d |  | Wewnętrzny dział relacji publicznych; Firma z branży relacji publicznych | 80h |
| 98 | 9.6 | Zrealizowanie strategii nagłaśniania |  | 5d? | 2023-11-01 | 2023-11-07 | 91 | 4d |  | Wewnętrzny dział relacji publicznych; Firma z branży relacji publicznych | 80h |
| 99 | 9.7 | Promocja — zakończenie zewnętrznej promocji | milestone | 0d | 2023-11-13 | 2023-11-13 | 98, 96, 97 | 0d |  |  |  |
| 100 | 10 | **Produkcja** |  | 14d? | 2023-11-14 | 2023-12-01 |  | 0d |  |  | 112h |
| 101 | 10.1 | Przesłanie materiałów kampanii w celu publikacji |  | 3d? | 2023-11-14 | 2023-11-16 | 99 | 0d |  | Przedstawiciel ds. marketingu | 24h |
| 102 | 10.2 | Wybranie dostawcy zgodnie z odpowiednimi metodami produkcji |  | 1d? | 2023-11-17 | 2023-11-17 | 101 | 20d | 0d | Personel działu marketingu | 8h |
| 103 | 10.3 | Produkcja materiałów |  | 5d? | 2023-11-20 | 2023-11-24 | 102 | 20d | 0d | Sprzedawca | 40h |
| 104 | 10.4 | Rozpowszechnienie materiałów |  | 5d? | 2023-11-27 | 2023-12-01 | 103 | 20d | 0d | Sprzedawca | 40h |
| 105 | 10.5 | Zakończenie produkcji | milestone | 0d | 2023-12-01 | 2023-12-01 | 104 | 20d |  |  |  |
| 106 | 11 | **Prowadzenie kampanii** |  | 13d? | 2023-11-17 | 2023-12-05 |  | 0d |  |  | 144h |
| 107 | 11.1 | Opracowanie harmonogramów prowadzenia kampanii |  | 2d? | 2023-11-17 | 2023-11-20 | 101 | 0d |  | Przedstawiciel ds. marketingu | 16h |
| 108 | 11.2 | Określenie zespołów ds. prowadzenia kampanii |  | 1d? | 2023-11-21 | 2023-11-21 | 107 | 0d |  | Lider marketingu | 8h |
| 109 | 11.3 | Wykonanie wezwań wewnętrznego działu sprzedaży |  | 5d? | 2023-11-22 | 2023-11-28 | 108 | 0d |  | Lider marketingu; Wewnętrzny dział sprzedaży | 80h |
| 110 | 11.4 | Realizacja kampanii |  | 5d? | 2023-11-29 | 2023-12-05 | 109 | 0d |  | Lider marketingu | 40h |
| 111 | 11.5 | Zakończenie realizacji kampanii | milestone | 0d | 2023-12-05 | 2023-12-05 | 110 | 0d |  |  |  |
| 112 | 12 | **Efektywność kampanii** |  | 18d? | 2023-12-06 | 2023-12-29 |  | 0d |  |  | 192h |
| 113 | 12.1 | Ocena efektywności kampanii |  | 3d? | 2023-12-06 | 2023-12-08 | 111 | 3d |  | Lider marketingu | 24h |
| 114 | 12.2 | Przegląd regionalnej sprzedaży |  | 1d? | 2023-12-06 | 2023-12-06 | 111 | 0d |  | Lider marketingu; Sprzedaż | 16h |
| 115 | 12.3 | Przegląd globalnej sprzedaży |  | 1d? | 2023-12-07 | 2023-12-07 | 114 | 0d |  | Lider marketingu; Sprzedaż | 16h |
| 116 | 12.4 | Przegląd danych i opinii klientów |  | 1d? | 2023-12-08 | 2023-12-08 | 115 | 0d |  | Personel działu marketingu; Przedstawiciel ds. marketingu | 16h |
| 117 | 12.5 | Przeprowadzenie analizy rynku |  | 3d? | 2023-12-11 | 2023-12-13 | 116 | 0d |  | Badania marketingowe | 24h |
| 118 | 12.6 | Przegląd miar sukcesu |  | 3d? | 2023-12-14 | 2023-12-18 | 113, 114, 115, 116, 117 | 0d |  | Lider marketingu | 24h |
| 119 | 12.7 | Ocena efektywności kampanii |  | 3d? | 2023-12-19 | 2023-12-21 | 118 | 0d |  | Lider marketingu | 24h |
| 120 | 12.8 | Zidentyfikowanie luk |  | 1d? | 2023-12-22 | 2023-12-22 | 119 | 0d |  | Lider marketingu | 8h |
| 121 | 12.9 | Opracowanie pomysłów na przyszłe kampanie |  | 5d? | 2023-12-25 | 2023-12-29 | 120 | 0d |  | Lider marketingu | 40h |
| 122 | 12.10 | Efektywność kampanii | milestone | 0d | 2023-12-29 | 2023-12-29 | 121 | 0d |  |  |  |
| 123 | 13 | Zakończenie planowania kampanii marketingowej | milestone | 0d | 2023-12-29 | 2023-12-29 | 122 | 0d |  |  |  |

Notes:
- 92: Możesz mieć bardziej szczegółowy harmonogram relacji publicznych na potrzeby zarządzania pracą w ramach tej części kampanii.
